# Ultra fast X-ray imaging of proceses ...

Schedule from MS Project, 2010-07-01 to 2012-06-27.

## Calendars

- Standard: Mon-Fri 08:00-12:00, 13:00-17:00; Sat-Sun off.

## Schedule

| ID | WBS | Task | Type | Duration | Start | Finish | Predecessors | Total slack | Free slack | Constraint | Work |
| --- | --- | --- | --- | --- | --- | --- | --- | --- | --- | --- | --- |
| 1 | 1 | **WP1: Overall system development and monitoring** |  | 180d? | 2010-07-01 | 2011-03-09 |  | 340d |  |  |  |
| 2 | 1.1 | **Task 1: Specification and design** |  | 180d? | 2010-07-01 | 2011-03-09 |  | 340d |  |  |  |
| 3 | 1.1.1 | Determination of performance requirements |  | 60d? | 2010-07-01 | 2010-09-22 |  | 340d | 0d |  |  |
| 4 | 1.1.2 | Determination of performance requirements |  | 3mo | 2010-07-01 | 2010-09-22 |  | 460d |  | start no earlier than 2010-07-01 | 8h |
| 5 | 1.1.3 | Overall system design |  | 3mo | 2010-09-23 | 2010-12-15 | 3 | 340d | 0d |  | 8h |
| 6 | 1.1.4 | Design review |  | 3mo | 2010-12-16 | 2011-03-09 | 5 | 340d |  |  | 8h |
| 7 | 2 | **WP2: X-ray imaging setup** |  | 520d | 2010-07-01 | 2012-06-27 |  | 0d |  |  |  |
| 8 | 2.1 | **Task 2.1: Development of sample manipulators, environment and changer** |  | 520d | 2010-07-01 | 2012-06-27 |  | 0d |  |  |  |
| 9 | 2.1.1 | Selection of motors, controllers and supporting components |  | 6mo | 2010-07-01 | 2010-12-15 |  | 0d |  |  |  |
| 10 | 2.1.2 | Mechanical design |  | 8mo | 2010-10-21 | 2011-06-01 | 9FS-2mo | 0d |  |  | 8h |
| 11 | 2.1.3 | Construction |  | 8mo | 2011-06-02 | 2012-01-11 | 48 | 0d |  |  | 8h |
| 12 | 2.1.4 | Device server programming |  | 4mo | 2011-04-07 | 2011-07-27 | 9FS+4mo | 120d | 0d |  | 8h |
| 13 | 2.1.5 | Signaling infrastructure |  | 4mo | 2011-06-02 | 2011-09-21 | 12SS+2mo | 200d |  |  | 8h |
| 14 | 2.1.6 | Test and optimization |  | 6mo | 2012-01-12 | 2012-06-27 | 11, 12 | 0d |  | finish no earlier than 2011-12-31 |  |
| 15 | 2.2 | **Task 2.2: Development of prototype detector system** |  | 348d | 2010-07-01 | 2011-10-31 |  | 129d |  |  |  |
| 16 | 2.2.1 | Selection of high speed CMOS-camera |  | 3mo | 2010-07-01 | 2010-09-22 |  | 129d | 0d | start no earlier than 2010-07-01 |  |
| 17 | 2.2.2 | Selection of direct converting detector |  | 2mo | 2010-09-23 | 2010-11-17 | 16 | 129d | 128d | start no earlier than 2010-07-01 | 8h |
| 18 | 2.2.3 | Evaluation of suitable lens design |  | 4mo | 2010-10-26 | 2011-02-14 | 16 | 177d | 5d | start no earlier than 2010-10-26 |  |
| 19 | 2.2.4 | Design manufacuring and installation of detector optics |  | 6mo | 2011-02-22 | 2011-08-08 | 18 | 172d | 0d | start no earlier than 2011-02-22 |  |
| 20 | 2.2.5 | Camera device server programming |  | 3mo | 2011-05-17 | 2011-08-08 | 16, 17 | 1d | 0d | start no earlier than 2011-05-17 |  |
| 21 | 2.2.6 | Evaluation of fast imaging detector | milestone | 3mo | 2011-08-09 | 2011-10-31 | 19, 20 | 172d |  |  |  |
| 22 | 3 | **WP3: Data processing, evaluation and visualization** |  | 520d? | 2010-07-01 | 2012-06-27 |  | 0d |  |  |  |
| 23 | 3.1 | **Task 3.1: Framework for parallel computation** |  | 520d | 2010-07-01 | 2012-06-27 |  | 0d |  |  |  |
| 24 | 3.1.1 | Assembly of GPU Computing Platform |  | 3mo | 2010-07-01 | 2010-09-22 |  | 0d |  |  |  |
| 25 | 3.1.2 | Investigation of expected implementations and specification of the requirements to the framework |  | 3mo | 2010-09-23 | 2010-12-15 | 24 | 0d |  | start no earlier than 2010-07-13 |  |
| 26 | 3.1.3 | Definition of standard interfaces and naming conventions, selection of parallel programming languages |  | 6mo | 2010-12-16 | 2011-06-01 | 25 | 0d |  |  |  |
| 27 | 3.1.4 | Development of infrastructural part of the framework |  | 8mo | 2011-06-02 | 2012-01-11 | 26 | 0d |  |  |  |
| 28 | 3.1.5 | Selection standard functions for image processing |  | 6mo | 2012-01-12 | 2012-06-27 | 27 | 0d |  | start no earlier than 2010-10-01 |  |

| ID | WBS | Task | Type | Duration | Start | Finish | Predecessors | Total slack | Free slack | Constraint | Work |
| --- | --- | --- | --- | --- | --- | --- | --- | --- | --- | --- | --- |
| 29 | 3.2 | **Task 3.2: Development of data processing and assessment algorithms for streamed data on parallel hardware** |  | 300d? | 2010-09-01 | 2011-10-25 |  | 176d |  | start no earlier than 2010-09-01 |  |
| 30 | 3.2.1 | Port of existing processing algorithms to parallel framework, setup of library with parallel executable code |  | 60d? | 2010-09-01 | 2010-11-23 |  | 176d | 0d |  |  |
| 31 | 3.2.2 | Port of existing processing algorithms to parallel framework, setup of library with parallel executable code |  | 3mo | 2010-11-05 | 2011-01-27 |  | 369d |  | start no earlier than 2010-11-05 |  |
| 32 | 3.2.3 | Reconstruction applications ported to parallel library for processing of stream of projections data |  | 6mo | 2010-11-24 | 2011-05-10 | 30 | 176d | 0d |  | 8h |
| 33 | 3.2.4 | Optimized algorithms for high-speed, high throuput setup, extension of the parallel code library |  | 6mo | 2011-05-11 | 2011-10-25 | 30, 32 | 176d |  |  |  |
| 34 | 3.3 | **Task 3.3: Graphical user interfaces and visualization of datasets** |  | 455d | 2010-09-29 | 2012-06-26 |  | 1d |  | start no earlier than 2010-07-01 |  |
| 35 | 3.3.1 | Selection of graphical user interface framework and programming languages |  | 3mo | 2010-09-29 | 2010-12-21 |  | 36d | 0d | start no earlier than 2010-09-29 |  |
| 36 | 3.3.2 | Functional prototypes of visualization and graphical user interfaces for parameter adjustments |  | 6mo | 2010-12-22 | 2011-06-07 | 35 | 36d | 35d |  | 8h |
| 37 | 3.3.3 | Production quality version of visualization and graphical user interfaces for parameter adjustments |  | 12mo | 2011-07-27 | 2012-06-26 | 36, 20FS-9d | 1d |  |  | 8h |
| 38 | 4 | **WP4: Development of online process control** |  | 289d? | 2010-09-01 | 2011-10-10 |  | 187d |  |  |  |
| 39 | 4.1 | **Task 4.1: Online fast data reject** |  | 220d? | 2010-09-01 | 2011-07-05 |  | 256d |  | start no earlier than 2010-09-01 |  |
| 40 | 4.1.1 | Selection of sample experiment |  | 20d? | 2010-09-01 | 2010-09-28 |  | 256d | 0d |  |  |
| 41 | 4.1.2 | Selection of sample experiment |  | 1mo | 2010-12-01 | 2010-12-28 |  | 391d |  | start no earlier than 2010-12-01 |  |
| 42 | 4.1.3 | Analysis of image characteristics |  | 2mo | 2010-09-29 | 2010-11-23 | 40 | 256d | 0d |  |  |
| 43 | 4.1.4 | Development fast reject algorithm for FPGA implementation |  | 7mo | 2010-11-24 | 2011-06-07 | 42 | 256d | 0d |  |  |
| 44 | 4.1.5 | Evaluation fast reject | milestone | 1mo | 2011-06-08 | 2011-07-05 | 43 | 256d |  |  |  |
| 45 | 4.2 | **Task 4.2: Development of control algorithms and feedback loops** |  | 200d | 2011-01-04 | 2011-10-10 |  | 107d |  |  |  |
| 46 | 4.2.1 | Selection of demonstrator application |  | 3mo | 2011-01-04 | 2011-03-28 |  | 187d | 0d | start no earlier than 2011-01-04 |  |
| 47 | 4.2.2 | Development of minmal control functions |  | 6mo | 2011-03-29 | 2011-09-12 | 46 | 187d | 0d |  |  |
| 48 | 4.2.3 | Evaluation mechanics for fast tomography | milestone | 0d | 2011-06-01 | 2011-06-01 | 10 | 0d |  |  |  |
| 49 | 4.2.4 | Evaluation of control loops | milestone | 1mo | 2011-09-13 | 2011-10-10 | 47 | 187d |  |  |  |
| 50 | 4.2.5 | Evaluation of reconstruction performance | milestone | 1mo | 2011-05-11 | 2011-06-07 | 32 | 276d |  |  |  |
